# Office Remodel

How a schedule from MS Project changed from version to version. A marks actual dates.

## Version 1 (saved 2013-07-08, file 2link.mpp)

| ID | WBS | Task | Duration | Start | Finish | Total float |
| --- | --- | --- | --- | --- | --- | --- |
| 1 | 1 | **Office Workspace Remodel** | 10d | 2013-10-07 | 2013-10-18 | 0d |
| 2 | 1.1 | **Space planning** | 5d | 2013-10-07 | 2013-10-11 | 5d |
| 3 |  | Interview space planners | 1w | 2013-10-07 | 2013-10-11 | 5d |
| 4 |  | Hire space planner | 2d | 2013-10-07 | 2013-10-08 | 8d |
| 5 |  | Meeting with space planner | 2d | 2013-10-07 | 2013-10-08 | 8d |
| 6 |  | Finalize space plan | 3d | 2013-10-07 | 2013-10-09 | 7d |
| 7 |  | Space plan complete | 0d | 2013-10-07 | 2013-10-07 | 10d |
| 8 | 1.2 | **Furniture selection** | 7.5d | 2013-10-07 | 2013-10-16 | 2.5d |
| 9 |  | Preview furniture selections | 2d | 2013-10-07 | 2013-10-08 | 8d |
| 10 |  | Select new furniture | 2d | 2013-10-07 | 2013-10-08 | 8d |
| 11 |  | Order new furniture | 0.5d | 2013-10-07 | 2013-10-07 | 9.5d |
| 12 |  | Delivery time | 1.5w | 2013-10-07 | 2013-10-16 | 2.5d |
| 13 |  | Furniture delivered | 0d | 2013-10-07 | 2013-10-07 | 10d |
| 14 | 1.3 | **Remodel workspace** | 10d | 2013-10-07 | 2013-10-18 | 0d |
| 15 |  | Hire contractor | 4d | 2013-10-07 | 2013-10-10 | 6d |
| 16 |  | Remodel workspace | 2w | 2013-10-07 | 2013-10-18 | 0d |
| 17 |  | Remodel complete | 0d | 2013-10-07 | 2013-10-07 | 10d |
| 18 | 1.4 | **New workspace** | 2d | 2013-10-07 | 2013-10-08 | 8d |
| 19 |  | Hire mover | 2d | 2013-10-07 | 2013-10-08 | 8d |
| 20 |  | Pack workspace | 1d | 2013-10-07 | 2013-10-07 | 9d |
| 21 |  | Move equipment | 0.5d | 2013-10-07 | 2013-10-07 | 9.5d |
| 22 |  | Remove existing furniture | 1d | 2013-10-07 | 2013-10-07 | 9d |
| 23 |  | Assemble new furniture | 2d | 2013-10-07 | 2013-10-08 | 8d |
| 24 |  | Return equipment | 1d | 2013-10-07 | 2013-10-07 | 9d |
| 25 |  | Unpack workspace | 1d | 2013-10-07 | 2013-10-07 | 9d |
| 26 |  | Workspace final clean | 1d | 2013-10-07 | 2013-10-07 | 9d |
| 27 |  | Workspace remodel complete | 0d | 2013-10-07 | 2013-10-07 | 10d |

## Version 2 (saved 2013-07-08, file 2outline.mpp)

Last finish stays 2013-10-18.

Removed: 4 Hire space planner; 11 Order new furniture

Changed:

| ID | Task | Finish | Duration | Total float |
| --- | --- | --- | --- | --- |
| 1 | Office Workspace Remodel | 2013-10-18 → 2013-10-07 (-11d) | 10d → 1d | 0d → 9d |
| 2 | Space planning | 2013-10-11 → 2013-10-07 (-4d) | 5d → 1d | 5d → 9d |
| 8 | Furniture selection | 2013-10-16 → 2013-10-07 (-9d) | 7.5d → 1d | 2.5d → 9d |
| 12 | Remodel workspace | 2013-10-18 → 2013-10-07 (-11d) | 10d → 1d | 0d → 9d |
| 16 | New workspace | 2013-10-08 → 2013-10-07 (-1d) | 2d → 1d | 8d → 9d |

## Version 3 (saved 2013-07-08, file 3costs.mpp)

Last finish 2013-10-18 → 2013-11-26 (+39d).

Added:

| ID | Task | Duration | Start | Finish | Predecessors | Resources |
| --- | --- | --- | --- | --- | --- | --- |
| 4 | Hire space planner | 2d | 2013-10-14 | 2013-10-15 | 3 | Administrative Assistant; Janitor |
| 11 | Order new furniture | 0.5d | 2013-10-24 | 2013-10-24 | 10 | Janitor |

Changed:

| ID | Task | Start | Finish | Duration | Total float | Predecessors | Other |
| --- | --- | --- | --- | --- | --- | --- | --- |
| 1 | **Office Workspace Remodel** |  | 2013-10-07 → 2013-11-26 (+50d) | 1d → 36.5d | 9d → 0d |  |  |
| 2 | **Space planning** |  | 2013-10-07 → 2013-10-22 (+15d) | 1d → 12d | 9d → 0d |  |  |
| 3 | Interview space planners |  |  |  | 5d → 0d |  | resources none → Administrative Assistant; Mover; Contractor |
| 5 | Meeting with space planner | 2013-10-07 → 2013-10-16 (+9d) | 2013-10-08 → 2013-10-17 (+9d) |  | 8d → 0d | none → 4 | resources none → Administrative Assistant; Contractor; Janitor; Mover; Office Manager |
| 6 | Finalize space plan | 2013-10-07 → 2013-10-18 (+11d) | 2013-10-09 → 2013-10-22 (+13d) |  | 7d → 0.88d | none → 5 | resources none → Office Manager |
| 7 | Space plan complete | 2013-10-07 → 2013-10-22 (+15d) | 2013-10-07 → 2013-10-22 (+15d) |  | 10d → 0.88d | none → 6 |  |
| 8 | **Furniture selection** | 2013-10-07 → 2013-10-17 (+10d) | 2013-10-07 → 2013-11-06 (+30d) | 1d → 15d | 9d → 13.5d |  |  |
| 9 | Preview furniture selections | 2013-10-07 → 2013-10-17 (+10d) | 2013-10-08 → 2013-10-21 (+13d) | 2d → 3d | 8d → 13.5d | none → 5SS+1d | resources none → Contractor; Mover; Janitor |
| 10 | Select new furniture | 2013-10-07 → 2013-10-22 (+15d) | 2013-10-08 → 2013-10-23 (+15d) |  | 8d → 13.5d | none → 9 | resources none → Contractor; Mover |
| 12 | Delivery time | 2013-10-07 → 2013-10-24 (+17d) | 2013-10-16 → 2013-11-06 (+21d) |  | 2.5d → 13.5d | none → 11 | resources none → Janitor [10%] |
| 13 | Furniture delivered | 2013-10-07 → 2013-11-06 (+30d) | 2013-10-07 → 2013-11-06 (+30d) |  | 10d → 13.5d | none → 12 |  |
| 14 | **Remodel workspace** | 2013-10-07 → 2013-10-23 (+16d) | 2013-10-07 → 2013-11-11 (+35d) | 1d → 14d | 9d → 0.88d |  |  |
| 15 | Hire contractor | 2013-10-07 → 2013-10-23 (+16d) | 2013-10-10 → 2013-10-28 (+18d) |  | 6d → 0.88d | none → 7 | resources none → Administrative Assistant; Mover |
| 16 | Remodel workspace | 2013-10-07 → 2013-10-29 (+22d) | 2013-10-18 → 2013-11-11 (+24d) |  | 0d → 0.88d | none → 15 | resources none → Space Planner |
| 17 | Remodel complete | 2013-10-07 → 2013-11-11 (+35d) | 2013-10-07 → 2013-11-11 (+35d) |  | 10d → 0.88d | none → 16 |  |
| 18 | **New workspace** | 2013-10-07 → 2013-11-12 (+36d) | 2013-10-07 → 2013-11-26 (+50d) | 1d → 10.5d | 9d → 0d | none → 14 |  |
| 19 | Hire mover | 2013-10-07 → 2013-11-12 (+36d) | 2013-10-08 → 2013-11-13 (+36d) |  | 8d → 0.88d |  | resources none → Contractor; Mover |
| 20 | Pack workspace | 2013-10-07 → 2013-11-14 (+38d) | 2013-10-07 → 2013-11-14 (+38d) |  | 9d → 0.88d | none → 19 | resources none → Mover; President |
| 21 | Move Equipment | 2013-10-07 → 2013-11-14 (+38d) | 2013-10-07 → 2013-11-14 (+38d) |  | 9.5d → 0.88d | none → 20FF | was named Move equipment; resources none → President; Mover |
| 22 | Remove existing furniture | 2013-10-07 → 2013-11-14 (+38d) | 2013-10-07 → 2013-11-18 (+42d) |  | 9d → 0.38d | none → 21 | resources none → President |
| 23 | Assemble new furniture | 2013-10-07 → 2013-11-19 (+43d) | 2013-10-08 → 2013-11-20 (+43d) |  | 8d → 0d | none → 22 | resources none → President; Office Manager |
| 24 | Return equipment | 2013-10-07 → 2013-11-20 (+44d) | 2013-10-07 → 2013-11-21 (+45d) |  | 9d → 0d | none → 23FS-0.5d | resources none → President; Mover |
| 25 | Unpack workspace | 2013-10-07 → 2013-11-21 (+45d) | 2013-10-07 → 2013-11-25 (+49d) | 1d → 1.5d | 9d → 0d | none → 24 | resources none → President; Janitor |
| 26 | Workspace final clean | 2013-10-07 → 2013-11-25 (+49d) | 2013-10-07 → 2013-11-26 (+50d) |  | 9d → 0d | none → 25 | resources none → Janitor |
| 27 | Workspace remodel complete | 2013-10-07 → 2013-11-26 (+50d) | 2013-10-07 → 2013-11-26 (+50d) |  | 10d → 0d | none → 18 |  |

## Version 4 (saved 2013-07-08, file 3projcal.mpp)

Last finish 2013-11-26 → 2013-11-22 (-4d).

Changed:

| ID | Task | Start | Finish | Duration | Total float | Other |
| --- | --- | --- | --- | --- | --- | --- |
| 1 | **Office Workspace Remodel** |  | 2013-11-26 → 2013-11-22 (-4d) | 36.5d → 34.5d |  |  |
| 3 | Interview space planners |  |  |  |  | resources Administrative Assistant; Mover; Contractor → President; Operations Manager; Office Manager |
| 4 | Hire space planner |  |  |  |  | resources Administrative Assistant; Janitor → President; Administrative Assistant |
| 5 | Meeting with space planner |  |  |  |  | resources Administrative Assistant; Contractor; Janitor; Mover; Office Manager → President; Office Manager; Administrative Assistant; Operations Manager; Space Planner |
| 6 | Finalize space plan |  |  |  | 0.88d → 0d | resources Office Manager → Space Planner |
| 8 | **Furniture selection** |  | 2013-11-06 → 2013-11-01 (-5d) | 15d → 12d | 13.5d → 14.5d |  |
| 9 | Preview furniture selections |  | 2013-10-21 → 2013-10-18 (-3d) | 3d → 2d | 13.5d → 14.5d | resources Contractor; Mover; Janitor → Office Manager; Operations Manager; Administrative Assistant |
| 10 | Select new furniture | 2013-10-22 → 2013-10-21 (-1d) | 2013-10-23 → 2013-10-22 (-1d) |  | 13.5d → 14.5d | resources Contractor; Mover → Office Manager; Operations Manager |
| 11 | Order new furniture | 2013-10-24 → 2013-10-23 (-1d) | 2013-10-24 → 2013-10-23 (-1d) |  | 13.5d → 14.5d | resources Janitor → Administrative Assistant |
| 12 | Delivery time | 2013-10-24 → 2013-10-23 (-1d) | 2013-11-06 → 2013-11-01 (-5d) |  | 13.5d → 14.5d | resources Janitor [10%] → Administrative Assistant [10%] |
| 13 | Furniture delivered | 2013-11-06 → 2013-11-01 (-5d) | 2013-11-06 → 2013-11-01 (-5d) |  | 13.5d → 14.5d |  |
| 15 | Hire contractor |  |  |  | 0.88d → 0d | resources Administrative Assistant; Mover → President; Operations Manager |
| 16 | Remodel workspace |  |  |  | 0.88d → 0d | resources Space Planner → Contractor |
| 18 | **New workspace** |  | 2013-11-26 → 2013-11-22 (-4d) | 10.5d → 8.5d |  |  |
| 19 | Hire mover |  |  |  | 0.88d → 0d | resources Contractor; Mover → Office Manager; Operations Manager |
| 20 | Pack workspace |  |  |  | 0.88d → 0d | resources Mover; President → Operations Manager; Mover |
| 21 | Move Equipment |  |  |  | 0.88d → 0d | resources President; Mover → Mover; Operations Manager |
| 22 | Remove existing furniture | 2013-11-14 → 2013-11-15 (+1d) | 2013-11-18 → 2013-11-15 (-3d) |  | 0.38d → 0d | resources President → Mover |
| 23 | Assemble new furniture | 2013-11-19 → 2013-11-18 (-1d) | 2013-11-20 → 2013-11-19 (-1d) |  |  | resources President; Office Manager → Mover; Space Planner |
| 24 | Return equipment | 2013-11-20 → 2013-11-19 (-1d) | 2013-11-21 → 2013-11-20 (-1d) |  |  | resources President; Mover → Mover; Operations Manager |
| 25 | Unpack workspace | 2013-11-21 → 2013-11-20 (-1d) | 2013-11-25 → 2013-11-21 (-4d) | 1.5d → 1d |  | resources President; Janitor → Mover; Administrative Assistant |
| 26 | Workspace final clean | 2013-11-25 → 2013-11-21 (-4d) | 2013-11-26 → 2013-11-22 (-4d) |  |  |  |
| 27 | Workspace remodel complete | 2013-11-26 → 2013-11-22 (-4d) | 2013-11-26 → 2013-11-22 (-4d) |  |  |  |

## Version 5 (saved 2013-07-08, file 3resource.mpp)

Last finish stays 2013-11-22.

Changed:

| ID | Task | Other |
| --- | --- | --- |
| 3 | Interview space planners | resources President; Operations Manager; Office Manager → none |
| 4 | Hire space planner | resources President; Administrative Assistant → none |
| 5 | Meeting with space planner | resources President; Office Manager; Administrative Assistant; Operations Manager; Space Planner → none |
| 6 | Finalize space plan | resources Space Planner → none |
| 9 | Preview furniture selections | resources Office Manager; Operations Manager; Administrative Assistant → none |
| 10 | Select new furniture | resources Office Manager; Operations Manager → none |
| 11 | Order new furniture | resources Administrative Assistant → none |
| 12 | Delivery time | resources Administrative Assistant [10%] → none |
| 15 | Hire contractor | resources President; Operations Manager → none |
| 16 | Remodel workspace | resources Contractor → none |
| 19 | Hire mover | resources Office Manager; Operations Manager → none |
| 20 | Pack workspace | resources Operations Manager; Mover → none |
| 21 | Move equipment | was named Move Equipment; resources Mover; Operations Manager → none |
| 22 | Remove existing furniture | resources Mover → none |
| 23 | Assemble new furniture | resources Mover; Space Planner → none |
| 24 | Return equipment | resources Mover; Operations Manager → none |
| 25 | Unpack workspace | resources Mover; Administrative Assistant → none |
| 26 | Workspace final clean | resources Janitor → none |

## Version 6 (saved 2013-07-08, file 3taskcal.mpp)

Last finish 2013-11-22 → 2013-11-25 (+3d).

Changed:

| ID | Task | Start | Finish | Duration | Total float | Other |
| --- | --- | --- | --- | --- | --- | --- |
| 1 | **Office Workspace Remodel** |  | 2013-11-22 → 2013-11-25 (+3d) | 34.5d → 35.5d |  |  |
| 3 | Interview space planners |  |  |  |  | resources none → President; Operations Manager; Office Manager |
| 4 | Hire space planner |  |  |  |  | resources none → President; Administrative Assistant |
| 5 | Meeting with space planner |  |  |  |  | resources none → President; Office Manager; Administrative Assistant; Operations Manager; Space Planner |
| 6 | Finalize space plan |  |  |  |  | resources none → Space Planner |
| 9 | Preview furniture selections |  |  |  | 14.5d → 15.5d | resources none → Office Manager; Operations Manager; Administrative Assistant |
| 10 | Select new furniture |  |  |  | 14.5d → 15.5d | resources none → Office Manager; Operations Manager |
| 11 | Order new furniture |  |  |  | 14.5d → 15.5d | resources none → Administrative Assistant |
| 12 | Delivery time |  |  |  | 14.5d → 15.5d | resources none → Administrative Assistant [10%] |
| 15 | Hire contractor |  |  |  |  | resources none → President; Operations Manager |
| 16 | Remodel workspace |  |  |  |  | resources none → Contractor |
| 18 | **New workspace** |  | 2013-11-22 → 2013-11-25 (+3d) | 8.5d → 9.5d |  |  |
| 19 | Hire mover |  |  |  |  | resources none → Office Manager; Operations Manager |
| 20 | Pack workspace |  |  |  |  | resources none → Operations Manager; Mover |
| 21 | Move Equipment |  |  |  |  | was named Move equipment; resources none → Mover; Operations Manager |
| 22 | Remove existing furniture |  |  |  |  | resources none → Mover |
| 23 | Assemble new furniture |  |  |  |  | resources none → Mover; Space Planner |
| 24 | Return equipment |  |  |  |  | resources none → Mover; Operations Manager |
| 25 | Unpack workspace |  |  |  |  | resources none → Mover; Administrative Assistant |
| 26 | Workspace final clean |  | 2013-11-22 → 2013-11-25 (+3d) |  |  | resources none → Janitor |
| 27 | Workspace remodel complete | 2013-11-22 → 2013-11-25 (+3d) | 2013-11-22 → 2013-11-25 (+3d) |  |  |  |

## Version 7 (saved 2013-07-08, file 4print.mpp)

Last finish stays 2013-11-25.

Changed:

| ID | Task | Start | Finish | Duration | Total float | Other |
| --- | --- | --- | --- | --- | --- | --- |
| 1 | **Office Workspace Remodel** |  |  | 35.5d → 36d |  |  |
| 3 | Interview space planners |  |  |  | 0d → 0.88d | resources President; Operations Manager; Office Manager → president; operations manager; office manager |
| 4 | Hire space planner |  |  |  | 0d → 0.88d | resources President; Administrative Assistant → president; administrative assistant |
| 5 | Meeting with space planner |  |  |  | 0d → 0.88d | resources President; Office Manager; Administrative Assistant; Operations Manager; Space Planner → president; office manager; administrative assistant; operations manager; space planner |
| 6 | Finalize space plan |  |  |  | 0d → 0.88d | resources Space Planner → space planner |
| 9 | Preview furniture selections |  |  |  | 15.5d → 16d | resources Office Manager; Operations Manager; Administrative Assistant → office manager; operations manager; administrative assistant |
| 10 | Select new furniture |  |  |  | 15.5d → 16d | resources Office Manager; Operations Manager → office manager; operations manager |
| 11 | Order new furniture |  |  |  | 15.5d → 16d | resources Administrative Assistant → administrative assistant |
| 12 | Delivery time |  |  |  | 15.5d → 16d | resources Administrative Assistant [10%] → administrative assistant [10%] |
| 15 | Hire contractor |  |  |  | 0d → 0.88d | resources President; Operations Manager → president; operations manager |
| 16 | Remodel workspace |  |  |  | 0d → 0.88d | resources Contractor → contractor |
| 18 | **New workspace** |  |  | 9.5d → 10d |  |  |
| 19 | Hire mover |  |  |  | 0d → 0.88d | resources Office Manager; Operations Manager → office manager; operations manager |
| 20 | Pack workspace |  |  |  | 0d → 0.88d | resources Operations Manager; Mover → operations manager; mover |
| 21 | Move Equipment |  |  |  | 0d → 0.88d | resources Mover; Operations Manager → mover; operations manager |
| 22 | Remove existing furniture | 2013-11-15 → 2013-11-14 (-1d) | 2013-11-15 → 2013-11-18 (+3d) |  | 0d → 0.38d | resources Mover → mover |
| 23 | Assemble new furniture | 2013-11-18 → 2013-11-19 (+1d) | 2013-11-19 → 2013-11-20 (+1d) |  | 0d → 0.5d | resources Mover; Space Planner → mover; space planner |
| 24 | Return equipment | 2013-11-19 → 2013-11-20 (+1d) | 2013-11-20 → 2013-11-21 (+1d) |  | 0d → 0.5d | resources Mover; Operations Manager → mover; operations manager |
| 25 | Unpack workspace | 2013-11-20 → 2013-11-21 (+1d) | 2013-11-21 → 2013-11-22 (+1d) |  | 0d → 0.5d | resources Mover; Administrative Assistant → mover; administrative assistant |
| 26 | Workspace final clean | 2013-11-21 → 2013-11-25 (+4d) |  |  |  | resources Janitor → janitor |

## Version 8 (saved 2013-07-08, file 5constraint.mpp)

Last finish 2013-11-25 → 2013-11-18 (-7d).

Changed:

| ID | Task | Start | Finish | Duration | Total float | Other |
| --- | --- | --- | --- | --- | --- | --- |
| 1 | **Office Workspace Remodel** |  | 2013-11-25 → 2013-11-18 (-7d) | 36d → 31d |  |  |
| 3 | Interview space planners |  |  |  |  | resources president; operations manager; office manager → President; Operations Manager; Office Manager |
| 4 | Hire space planner |  |  |  |  | resources president; administrative assistant → President; Administrative Assistant |
| 5 | Meeting with space planner |  |  |  |  | resources president; office manager; administrative assistant; operations manager; space planner → President; Office Manager; Administrative Assistant; Operations Manager; Space Planner |
| 6 | Finalize space plan |  |  |  |  | resources space planner → Space Planner |
| 8 | **Furniture selection** |  | 2013-11-01 → 2013-10-31 (-1d) | 12d → 11d | 16d → 12d |  |
| 9 | Preview furniture selections |  |  |  | 16d → 12d | resources office manager; operations manager; administrative assistant → Office Manager; Operations Manager; Administrative Assistant |
| 10 | Select new furniture |  | 2013-10-22 → 2013-10-21 (-1d) | 2d → 1d | 16d → 12d | resources office manager; operations manager → Office Manager; Operations Manager |
| 11 | Order new furniture | 2013-10-23 → 2013-10-22 (-1d) | 2013-10-23 → 2013-10-22 (-1d) |  | 16d → 12d | resources administrative assistant → Administrative Assistant |
| 12 | Delivery time | 2013-10-23 → 2013-10-22 (-1d) | 2013-11-01 → 2013-10-31 (-1d) |  | 16d → 12d | resources administrative assistant [10%] → Administrative Assistant [10%] |
| 13 | Furniture delivered | 2013-11-01 → 2013-10-31 (-1d) | 2013-11-01 → 2013-10-31 (-1d) |  | 16d → 12d |  |
| 14 | **Remodel workspace** |  | 2013-11-11 → 2013-11-04 (-7d) | 14d → 9d |  |  |
| 15 | Hire contractor |  |  |  |  | resources president; operations manager → President; Operations Manager |
| 16 | Remodel workspace |  | 2013-11-11 → 2013-11-04 (-7d) | 2w → 1w |  | resources contractor → Contractor [200%] |
| 17 | Remodel complete | 2013-11-11 → 2013-11-04 (-7d) | 2013-11-11 → 2013-11-04 (-7d) |  |  |  |
| 18 | **New workspace** | 2013-11-12 → 2013-11-05 (-7d) | 2013-11-25 → 2013-11-18 (-7d) |  |  |  |
| 19 | Hire mover | 2013-11-12 → 2013-11-05 (-7d) | 2013-11-13 → 2013-11-06 (-7d) |  |  | resources office manager; operations manager → Office Manager; Operations Manager |
| 20 | Pack workspace | 2013-11-14 → 2013-11-07 (-7d) | 2013-11-14 → 2013-11-07 (-7d) |  |  | resources operations manager; mover → Operations Manager; Mover |
| 21 | Move Equipment | 2013-11-14 → 2013-11-07 (-7d) | 2013-11-14 → 2013-11-07 (-7d) |  |  | resources mover; operations manager → Mover; Operations Manager |
| 22 | Remove existing furniture | 2013-11-14 → 2013-11-07 (-7d) | 2013-11-18 → 2013-11-11 (-7d) |  |  | resources mover → Mover |
| 23 | Assemble new furniture | 2013-11-19 → 2013-11-12 (-7d) | 2013-11-20 → 2013-11-13 (-7d) |  | 0.5d → 0d | resources mover; space planner → Mover; Space Planner |
| 24 | Return equipment | 2013-11-20 → 2013-11-13 (-7d) | 2013-11-21 → 2013-11-14 (-7d) |  | 0.5d → 0d | resources mover; operations manager → Mover; Operations Manager |
| 25 | Unpack workspace | 2013-11-21 → 2013-11-14 (-7d) | 2013-11-22 → 2013-11-15 (-7d) |  | 0.5d → 0d | resources mover; administrative assistant → Mover; Administrative Assistant |
| 26 | Workspace final clean | 2013-11-25 → 2013-11-15 (-10d) | 2013-11-25 → 2013-11-18 (-7d) | 1d → 1.5d |  | resources janitor → Janitor [50%]; Mover [50%] |
| 27 | Workspace remodel complete | 2013-11-25 → 2013-11-18 (-7d) | 2013-11-25 → 2013-11-18 (-7d) |  |  |  |

## Version 9 (saved 2013-07-08, file 5critical.mpp)

Last finish 2013-11-18 → 2013-11-20 (+2d).

Changed:

| ID | Task | Start | Finish | Duration | Total float | Predecessors | Other |
| --- | --- | --- | --- | --- | --- | --- | --- |
| 1 | **Office Workspace Remodel** |  | 2013-11-18 → 2013-11-20 (+2d) | 31d → 32d |  |  |  |
| 5 | Meeting w/space planner |  |  |  | 0.88d → 0d |  | was named Meeting with space planner |
| 12 | Delivery time |  |  |  | 12d → 13d |  | constraint none → finish no earlier than 2009-11-01 |
| 18 | **New workspace** |  | 2013-11-18 → 2013-11-19 (+1d) | 10d → 11d |  |  |  |
| 24 | Return equipment | 2013-11-13 → 2013-11-14 (+1d) |  |  |  | 23FS-0.5d → 23 |  |
| 25 | Unpack workspace | 2013-11-14 → 2013-11-15 (+1d) | 2013-11-15 → 2013-11-18 (+3d) | 1d → 2d |  |  |  |
| 26 | Workspace final clean | 2013-11-15 → 2013-11-19 (+4d) | 2013-11-18 → 2013-11-19 (+1d) | 1.5d → 1d |  |  |  |
| 27 | Workspace remodel complete | 2013-11-18 → 2013-11-20 (+2d) | 2013-11-18 → 2013-11-20 (+2d) |  |  | 18 → 18, 26 | constraint none → must finish on 2013-11-20 |

## Version 10 (saved 2013-07-08, file 5tasktype.mpp)

Last finish 2013-11-20 → 2013-11-25 (+5d).

Changed:

| ID | Task | Start | Finish | Duration | Total float | Predecessors | Other |
| --- | --- | --- | --- | --- | --- | --- | --- |
| 1 | **Office Workspace Remodel** |  | 2013-11-20 → 2013-11-25 (+5d) | 32d → 36d |  |  |  |
| 5 | Meeting with space planner |  |  |  | 0d → 0.88d |  | was named Meeting w/space planner |
| 8 | **Furniture selection** |  | 2013-10-31 → 2013-11-01 (+1d) | 11d → 12d | 13d → 16d |  |  |
| 10 | Select new furniture |  | 2013-10-21 → 2013-10-22 (+1d) | 1d → 2d | 13d → 16d |  | resources Office Manager; Operations Manager → Office Manager |
| 11 | Order new furniture | 2013-10-22 → 2013-10-23 (+1d) | 2013-10-22 → 2013-10-23 (+1d) |  | 13d → 16d |  |  |
| 12 | Delivery time | 2013-10-22 → 2013-10-23 (+1d) | 2013-10-31 → 2013-11-01 (+1d) |  | 13d → 16d |  | constraint finish no earlier than 2009-11-01 → none |
| 13 | Furniture delivered | 2013-10-31 → 2013-11-01 (+1d) | 2013-10-31 → 2013-11-01 (+1d) |  | 13d → 16d |  |  |
| 14 | **Remodel workspace** |  | 2013-11-04 → 2013-11-11 (+7d) | 9d → 14d |  |  |  |
| 16 | Remodel workspace |  | 2013-11-04 → 2013-11-11 (+7d) | 1w → 2w |  |  | resources Contractor [200%] → Contractor |
| 17 | Remodel complete | 2013-11-04 → 2013-11-11 (+7d) | 2013-11-04 → 2013-11-11 (+7d) |  |  |  |  |
| 18 | **New workspace** | 2013-11-05 → 2013-11-12 (+7d) | 2013-11-19 → 2013-11-25 (+6d) | 11d → 10d |  |  |  |
| 19 | Hire mover | 2013-11-05 → 2013-11-12 (+7d) | 2013-11-06 → 2013-11-13 (+7d) |  |  |  |  |
| 20 | Pack workspace | 2013-11-07 → 2013-11-14 (+7d) | 2013-11-07 → 2013-11-14 (+7d) |  |  |  |  |
| 21 | Move Equipment | 2013-11-07 → 2013-11-14 (+7d) | 2013-11-07 → 2013-11-14 (+7d) |  |  |  |  |
| 22 | Remove existing furniture | 2013-11-07 → 2013-11-14 (+7d) | 2013-11-11 → 2013-11-18 (+7d) |  |  |  |  |
| 23 | Assemble new furniture | 2013-11-12 → 2013-11-19 (+7d) | 2013-11-13 → 2013-11-20 (+7d) |  | 0d → 0.5d |  |  |
| 24 | Return equipment | 2013-11-14 → 2013-11-20 (+6d) | 2013-11-14 → 2013-11-21 (+7d) |  | 0d → 0.5d | 23 → 23FS-0.5d |  |
| 25 | Unpack workspace | 2013-11-15 → 2013-11-21 (+6d) | 2013-11-18 → 2013-11-22 (+4d) | 2d → 1d | 0d → 0.5d |  |  |
| 26 | Workspace final clean | 2013-11-19 → 2013-11-25 (+6d) | 2013-11-19 → 2013-11-25 (+6d) |  |  |  | resources Janitor [50%]; Mover [50%] → Janitor |
| 27 | Workspace remodel complete | 2013-11-20 → 2013-11-25 (+5d) | 2013-11-20 → 2013-11-25 (+5d) |  |  | 18, 26 → 18 | constraint must finish on 2013-11-20 → none |

## Version 11 (saved 2013-07-08, file 6baseline.mpp)

Last finish 2013-11-25 → 2013-11-20 (-5d).

Changed:

| ID | Task | Start | Finish | Duration | Total float | Predecessors | Other |
| --- | --- | --- | --- | --- | --- | --- | --- |
| 1 | **Office Workspace Remodel** |  | 2013-11-25 → 2013-11-20 (-5d) | 36d → 32d |  |  |  |
| 3 | Interview space planners |  |  |  | 0.88d → 0d |  | resources President; Operations Manager; Office Manager → Operations Manager; Office Manager; President [25%] |
| 8 | **Furniture selection** | 2013-10-17 → 2013-10-21 (+4d) | 2013-11-01 → 2013-11-05 (+4d) |  | 16d → 10d |  |  |
| 9 | Preview furniture selections | 2013-10-17 → 2013-10-21 (+4d) | 2013-10-18 → 2013-10-23 (+5d) | 2d → 3d | 16d → 10d |  | resources Office Manager; Operations Manager; Administrative Assistant → Office Manager; Administrative Assistant |
| 10 | Select new furniture | 2013-10-21 → 2013-10-24 (+3d) | 2013-10-22 → 2013-10-24 (+2d) | 2d → 1d | 16d → 10d |  |  |
| 11 | Order new furniture | 2013-10-23 → 2013-10-25 (+2d) | 2013-10-23 → 2013-10-25 (+2d) |  | 16d → 10d |  |  |
| 12 | Delivery time | 2013-10-23 → 2013-10-25 (+2d) | 2013-11-01 → 2013-11-05 (+4d) |  | 16d → 10d |  | constraint none → finish no earlier than 2009-11-01 |
| 13 | Furniture delivered | 2013-11-01 → 2013-11-05 (+4d) | 2013-11-01 → 2013-11-05 (+4d) |  | 16d → 10d |  |  |
| 14 | **Remodel workspace** |  | 2013-11-11 → 2013-11-04 (-7d) | 14d → 9d | 0.88d → 0d |  |  |
| 16 | Remodel workspace |  | 2013-11-11 → 2013-11-04 (-7d) | 2w → 1w | 0.88d → 0d |  | resources Contractor → Contractor [200%] |
| 17 | Remodel complete | 2013-11-11 → 2013-11-04 (-7d) | 2013-11-11 → 2013-11-04 (-7d) |  | 0.88d → 0d |  |  |
| 18 | **New workspace** | 2013-11-12 → 2013-11-05 (-7d) | 2013-11-25 → 2013-11-19 (-6d) | 10d → 10.5d |  |  |  |
| 19 | Hire mover | 2013-11-12 → 2013-11-05 (-7d) | 2013-11-13 → 2013-11-06 (-7d) |  | 0.88d → 0d | none → 15SS |  |
| 20 | Pack workspace | 2013-11-14 → 2013-11-07 (-7d) | 2013-11-14 → 2013-11-07 (-7d) |  | 0.88d → 0d | 19 → 19, 15 | resources Operations Manager; Mover → Operations Manager; Janitor |
| 21 | Move Equipment | 2013-11-14 → 2013-11-07 (-7d) | 2013-11-14 → 2013-11-07 (-7d) |  |  |  | resources Mover; Operations Manager → Mover; Office Manager |
| 22 | Remove existing furniture | 2013-11-14 → 2013-11-07 (-7d) | 2013-11-18 → 2013-11-11 (-7d) |  |  |  |  |
| 23 | Assemble new furniture | 2013-11-19 → 2013-11-12 (-7d) | 2013-11-20 → 2013-11-13 (-7d) |  | 0.5d → 0d | 22 → 22, 16 | resources Mover; Space Planner → Office Manager; Space Planner [125%] |
| 24 | Return equipment | 2013-11-20 → 2013-11-13 (-7d) | 2013-11-21 → 2013-11-14 (-7d) |  |  |  |  |
| 25 | Unpack workspace | 2013-11-21 → 2013-11-14 (-7d) | 2013-11-22 → 2013-11-18 (-4d) | 1d → 2d |  |  |  |
| 26 | Workspace final clean | 2013-11-25 → 2013-11-18 (-7d) | 2013-11-25 → 2013-11-19 (-6d) |  | 0d → 0.5d |  | resources Janitor → Janitor [50%]; Mover [50%] |
| 27 | Workspace remodel complete | 2013-11-25 → 2013-11-20 (-5d) | 2013-11-25 → 2013-11-20 (-5d) |  |  | 18 → 26 | constraint none → must finish on 2013-11-20 |

## Version 12 (saved 2013-07-08, file 6leveling.mpp)

Last finish stays 2013-11-20.

Changed:

| ID | Task | Start | Finish | Duration | Total float | Other |
| --- | --- | --- | --- | --- | --- | --- |
| 8 | **Furniture selection** | 2013-10-21 → 2013-10-17 (-4d) | 2013-11-05 → 2013-10-31 (-5d) | 12d → 11d | 10d → 13d |  |
| 9 | Preview furniture selections | 2013-10-21 → 2013-10-17 (-4d) | 2013-10-23 → 2013-10-18 (-5d) | 3d → 2d | 10d → 13d | resources Office Manager; Administrative Assistant → Office Manager; Operations Manager; Administrative Assistant |
| 10 | Select new furniture | 2013-10-24 → 2013-10-21 (-3d) | 2013-10-24 → 2013-10-21 (-3d) |  | 10d → 13d | resources Office Manager → Office Manager; Operations Manager |
| 11 | Order new furniture | 2013-10-25 → 2013-10-22 (-3d) | 2013-10-25 → 2013-10-22 (-3d) |  | 10d → 13d |  |
| 12 | Delivery time | 2013-10-25 → 2013-10-22 (-3d) | 2013-11-05 → 2013-10-31 (-5d) |  | 10d → 13d |  |
| 13 | Furniture delivered | 2013-11-05 → 2013-10-31 (-5d) | 2013-11-05 → 2013-10-31 (-5d) |  | 10d → 13d |  |
| 20 | Pack workspace |  |  |  | 0d → 0.88d | resources Operations Manager; Janitor → Operations Manager; Mover |
| 21 | Move Equipment |  |  |  |  | resources Mover; Office Manager → Mover; Operations Manager |
| 23 | Assemble new furniture |  |  |  |  | resources Office Manager; Space Planner [125%] → Mover; Space Planner [125%] |

## Version 13 (saved 2013-07-08, file 6contours.mpp)

Last finish stays 2013-11-20.

Changed:

| ID | Task | Other |
| --- | --- | --- |
| 23 | Assemble new furniture | resources Mover; Space Planner [125%] → Mover; Space Planner |

## Version 14 (saved 2013-07-08, file 6resolving.mpp)

Last finish stays 2013-11-20.

Changed:

| ID | Task | Other |
| --- | --- | --- |
| 21 | Move Equipment | resources Mover; Operations Manager → Mover; Office Manager |
| 23 | Assemble new furniture | resources Mover; Space Planner → Mover; Space Planner [125%] |

## Version 15 (saved 2013-07-08, file 6locating.mpp)

Last finish stays 2013-11-20.

Changed:

| ID | Task | Other |
| --- | --- | --- |
| 21 | Move Equipment | resources Mover; Office Manager → Mover; Operations Manager |

## Version 16 (data date 2010-01-09, saved 2013-07-08, file 9formatting.mpp)

Last finish 2013-11-20 → 2013-11-12 (-8d). Complete tasks 0 → 15.

Changed:

| ID | Task | Start | Finish | Duration | Complete | Total float | Predecessors | Other |
| --- | --- | --- | --- | --- | --- | --- | --- | --- |
| 1 | **Office Workspace Remodel** | 2013-10-07 A | 2013-11-20 → 2013-11-12 (-8d) | 32d → 27d | 0% → 88% |  |  |  |
| 2 | **Space planning** | 2013-10-07 A | 2013-10-22 → 2013-10-23 A (+1d) | 12d → 13d | 0% → 100% | 0.88d → none |  |  |
| 3 | Interview space planners | 2013-10-07 A | 2013-10-11 A |  | 0% → 100% | 0.88d → none |  |  |
| 4 | Hire space planner | 2013-10-14 A | 2013-10-15 → 2013-10-14 A (-1d) | 2d → 1d | 0% → 100% | 0.88d → none |  |  |
| 5 | Meeting with space planner | 2013-10-16 → 2013-10-15 A (-1d) | 2013-10-17 A | 2d → 3d | 0% → 100% | 0.88d → none |  |  |
| 6 | Finalize space plan | 2013-10-18 → 2013-10-21 A (+3d) | 2013-10-22 → 2013-10-23 A (+1d) |  | 0% → 100% | 0.88d → none |  |  |
| 7 | Space plan complete | 2013-10-22 A | 2013-10-22 A |  | 0% → 100% | 0.88d → none |  |  |
| 8 | **Furniture selection** | 2013-10-17 → 2013-10-21 A (+4d) | 2013-10-31 → 2013-11-04 A (+4d) | 11d → 10.5d | 0% → 100% | 13d → none |  |  |
| 9 | Preview furniture selections | 2013-10-17 → 2013-10-21 A (+4d) | 2013-10-18 → 2013-10-22 A (+4d) |  | 0% → 100% | 13d → none |  |  |
| 10 | Select new furniture | 2013-10-21 → 2013-10-22 A (+1d) | 2013-10-21 → 2013-10-23 A (+2d) | 1d → 1.5d | 0% → 100% | 13d → none |  |  |
| 11 | Order new furniture | 2013-10-22 → 2013-10-23 A (+1d) | 2013-10-22 → 2013-10-23 A (+1d) |  | 0% → 100% | 13d → none |  |  |
| 12 | Delivery time | 2013-10-22 → 2013-10-24 A (+2d) | 2013-10-31 → 2013-11-04 A (+4d) |  | 0% → 100% | 13d → none |  | constraint finish no earlier than 2009-11-01 → finish no earlier than 2011-11-02 |
| 13 | Furniture delivered | 2013-10-31 → 2013-11-01 A (+1d) | 2013-10-31 → 2013-11-01 A (+1d) |  | 0% → 100% | 13d → none |  |  |
| 14 | **Remodel workspace** | 2013-10-23 A | 2013-11-04 → 2013-11-05 (+1d) |  | 0% → 94% | 0.88d → 6d |  |  |
| 15 | Hire contractor | 2013-10-23 A | 2013-10-28 A |  | 0% → 100% | 0.88d → none |  |  |
| 16 | Remodel workspace | 2013-10-29 A |  |  | 0% → 90% | 0.88d → 1.5d |  |  |
| 17 | Remodel complete | 2013-11-04 → 2013-11-05 (+1d) | 2013-11-04 → 2013-11-05 (+1d) |  |  | 0.88d → 6d |  | constraint none → start no earlier than 2013-11-05 |
| 18 | **New workspace** | 2013-11-05 → 2013-10-23 A (-13d) | 2013-11-19 → 2013-11-12 (-7d) | 10.5d → 15d | 0% → 57% | 0.5d → 0d | 14 → none |  |
| 19 | Hire mover | 2013-11-05 → 2013-10-23 A (-13d) | 2013-11-06 → 2013-10-28 A (-9d) | 2d → 4d | 0% → 100% | 0.88d → none |  | resources Office Manager; Operations Manager → Office Manager |
| 20 | Pack workspace | 2013-11-07 → 2013-10-29 A (-9d) | 2013-11-07 → 2013-10-29 A (-9d) |  | 0% → 100% | 0.88d → none |  | resources Operations Manager; Mover → President; Janitor |
| 21 | Move Equipment | 2013-11-07 → 2013-10-29 A (-9d) | 2013-11-07 → 2013-10-29 A (-9d) |  | 0% → 100% | 0.88d → none |  |  |
| 22 | Remove existing furniture | 2013-11-07 → 2013-10-30 A (-8d) | 2013-11-11 → 2013-10-30 A (-12d) |  | 0% → 100% | 0.38d → none |  |  |
| 23 | Assemble new furniture | 2013-11-12 → 2013-11-05 (-7d) | 2013-11-13 → 2013-11-06 (-7d) |  |  | 0d → 1.5d |  | resources Mover; Space Planner [125%] → Office Manager; Space Planner [116.7%] |
| 24 | Return equipment | 2013-11-13 → 2013-11-06 (-7d) | 2013-11-14 → 2013-11-07 (-7d) |  |  | 0.5d → 1.5d |  |  |
| 25 | Unpack workspace | 2013-11-14 → 2013-11-11 (-3d) | 2013-11-18 → 2013-11-11 (-7d) | 2d → 1d |  | 0.5d → 0d |  | constraint none → start no earlier than 2013-11-09 |
| 26 | Workspace final clean | 2013-11-18 → 2013-11-12 (-6d) | 2013-11-19 → 2013-11-12 (-7d) |  |  | 0.5d → 0d |  | constraint none → start no earlier than 2013-11-09 |
| 27 | Workspace remodel complete | 2013-11-20 → 2013-11-12 (-8d) | 2013-11-20 → 2013-11-12 (-8d) |  |  |  | 26 → 18 | constraint must finish on 2013-11-20 → start no earlier than 2013-11-12 |

## Version 17 (saved 2013-07-28, file 2depend.mpp)

Last finish 2013-11-12 → 2013-11-25 (+13d). Complete tasks 15 → 0.

Changed:

| ID | Task | Start | Finish | Duration | Complete | Total float | Predecessors | Other |
| --- | --- | --- | --- | --- | --- | --- | --- | --- |
| 1 | **Office Workspace Remodel** | 2013-10-07 A → 2013-10-07 | 2013-11-12 → 2013-11-25 (+13d) | 27d → 35.5d | 88% → 0% |  |  |  |
| 2 | **Space planning** | 2013-10-07 A → 2013-10-07 | 2013-10-23 A → 2013-10-22 (-1d) | 13d → 12d | 100% → 0% | none → 0d |  |  |
| 3 | Interview space planners | 2013-10-07 A → 2013-10-07 | 2013-10-11 A → 2013-10-11 |  | 100% → 0% | none → 0d |  | resources Operations Manager; Office Manager; President [25%] → none |
| 4 | Hire space planner | 2013-10-14 A → 2013-10-14 | 2013-10-14 A → 2013-10-15 (+1d) | 1d → 2d | 100% → 0% | none → 0d |  | resources President; Administrative Assistant → none |
| 5 | Meeting with space planner | 2013-10-15 A → 2013-10-16 (+1d) | 2013-10-17 A → 2013-10-17 | 3d → 2d | 100% → 0% | none → 0d |  | resources President; Office Manager; Administrative Assistant; Operations Manager; Space Planner → none |
| 6 | Finalize space plan | 2013-10-21 A → 2013-10-18 (-3d) | 2013-10-23 A → 2013-10-22 (-1d) |  | 100% → 0% | none → 0d |  | resources Space Planner → none |
| 7 | Space plan complete | 2013-10-22 A → 2013-10-22 | 2013-10-22 A → 2013-10-22 |  | 100% → 0% | none → 0d |  |  |
| 8 | **Furniture selection** | 2013-10-21 A → 2013-10-18 (-3d) | 2013-11-04 A → 2013-11-04 | 10.5d → 12d | 100% → 0% | none → 14.5d |  |  |
| 9 | Preview furniture selections | 2013-10-21 A → 2013-10-18 (-3d) | 2013-10-22 A → 2013-10-21 (-1d) |  | 100% → 0% | none → 14.5d | 5SS+1d → 5 | resources Office Manager; Operations Manager; Administrative Assistant → none |
| 10 | Select new furniture | 2013-10-22 A → 2013-10-22 | 2013-10-23 A → 2013-10-23 | 1.5d → 2d | 100% → 0% | none → 14.5d |  | resources Office Manager; Operations Manager → none |
| 11 | Order new furniture | 2013-10-23 A → 2013-10-24 (+1d) | 2013-10-23 A → 2013-10-24 (+1d) |  | 100% → 0% | none → 14.5d |  | resources Administrative Assistant → none |
| 12 | Delivery time | 2013-10-24 A → 2013-10-24 | 2013-11-04 A → 2013-11-04 |  | 100% → 0% | none → 14.5d |  | constraint finish no earlier than 2011-11-02 → none; resources Administrative Assistant [10%] → none |
| 13 | Furniture delivered | 2013-11-01 A → 2013-11-04 (+3d) | 2013-11-01 A → 2013-11-04 (+3d) |  | 100% → 0% | none → 14.5d |  |  |
| 14 | **Remodel workspace** | 2013-10-23 A → 2013-10-23 | 2013-11-05 → 2013-11-11 (+6d) | 9d → 14d | 94% → 0% | 6d → 0d |  |  |
| 15 | Hire contractor | 2013-10-23 A → 2013-10-23 | 2013-10-28 A → 2013-10-28 |  | 100% → 0% | none → 0d |  | resources President; Operations Manager → none |
| 16 | Remodel workspace | 2013-10-29 A → 2013-10-29 | 2013-11-04 → 2013-11-11 (+7d) | 1w → 2w | 90% → 0% | 1.5d → 0d |  | resources Contractor [200%] → none |
| 17 | Remodel complete | 2013-11-05 → 2013-11-11 (+6d) | 2013-11-05 → 2013-11-11 (+6d) |  |  | 6d → 0d |  | constraint start no earlier than 2013-11-05 → none |
| 18 | **New workspace** | 2013-10-23 A → 2013-11-12 (+20d) | 2013-11-12 → 2013-11-25 (+13d) | 15d → 9.5d | 57% → 0% |  | none → 14 |  |
| 19 | Hire mover | 2013-10-23 A → 2013-11-12 (+20d) | 2013-10-28 A → 2013-11-13 (+16d) | 4d → 2d | 100% → 0% | none → 0d | 15SS → none | resources Office Manager → none |
| 20 | Pack workspace | 2013-10-29 A → 2013-11-14 (+16d) | 2013-10-29 A → 2013-11-14 (+16d) |  | 100% → 0% | none → 0d | 19, 15 → 19 | resources President; Janitor → none |
| 21 | Move equipment | 2013-10-29 A → 2013-11-15 (+17d) | 2013-10-29 A → 2013-11-15 (+17d) |  | 100% → 0% | none → 0d | 20FF → 20 | was named Move Equipment; resources Mover; Operations Manager → none |
| 22 | Remove existing furniture | 2013-10-30 A → 2013-11-15 (+16d) | 2013-10-30 A → 2013-11-18 (+19d) |  | 100% → 0% | none → 0d |  | resources Mover → none |
| 23 | Assemble new furniture | 2013-11-05 → 2013-11-18 (+13d) | 2013-11-06 → 2013-11-20 (+14d) |  |  | 1.5d → 0d | 22, 16 → 22 | resources Office Manager; Space Planner [116.7%] → none |
| 24 | Return equipment | 2013-11-06 → 2013-11-20 (+14d) | 2013-11-07 → 2013-11-21 (+14d) |  |  | 1.5d → 0d | 23FS-0.5d → 23 | resources Mover; Operations Manager → none |
| 25 | Unpack workspace | 2013-11-11 → 2013-11-21 (+10d) | 2013-11-11 → 2013-11-22 (+11d) |  |  |  |  | constraint start no earlier than 2013-11-09 → none; resources Mover; Administrative Assistant → none |
| 26 | Workspace final clean | 2013-11-12 → 2013-11-22 (+10d) | 2013-11-12 → 2013-11-25 (+13d) |  |  |  |  | constraint start no earlier than 2013-11-09 → none; resources Janitor [50%]; Mover [50%] → none |
| 27 | Workspace remodel complete | 2013-11-12 → 2013-11-25 (+13d) | 2013-11-12 → 2013-11-25 (+13d) |  |  |  |  | constraint start no earlier than 2013-11-12 → none |

## Version 18 (data date 2013-11-04, saved 2013-08-02, file 7compare.mpp)

Last finish 2013-11-25 → 2013-11-22 (-3d). Complete tasks 0 → 11.

Changed:

| ID | Task | Start | Finish | Duration | Complete | Total float | Predecessors | Other |
| --- | --- | --- | --- | --- | --- | --- | --- | --- |
| 1 | **Office Workspace Remodel** | 2013-10-07 A | 2013-11-25 → 2013-11-22 (-3d) | 35.5d → 34d | 0% → 74% |  |  | baseline start none → 2013-10-07; baseline finish none → 2013-11-22 |
| 2 | **Space planning** | 2013-10-07 A | 2013-10-22 → 2013-10-23 A (+1d) | 12d → 13d | 0% → 100% | 0d → none |  | baseline start none → 2013-10-07; baseline finish none → 2013-10-23 |
| 3 | Interview space planners | 2013-10-07 A | 2013-10-11 A |  | 0% → 100% | 0d → none |  | resources none → Operations Manager; Office Manager; President [25%]; baseline start none → 2013-10-07; baseline finish none → 2013-10-11 |
| 4 | Hire space planner | 2013-10-14 A | 2013-10-15 A |  | 0% → 100% | 0d → none |  | resources none → President; Administrative Assistant; baseline start none → 2013-10-14; baseline finish none → 2013-10-15 |
| 5 | Meeting with space planner | 2013-10-16 A | 2013-10-17 A |  | 0% → 100% | 0d → none |  | resources none → President; Office Manager; Administrative Assistant; Operations Manager; Space Planner; baseline start none → 2013-10-16; baseline finish none → 2013-10-17 |
| 6 | Finalize space plan | 2013-10-18 → 2013-10-21 A (+3d) | 2013-10-22 → 2013-10-23 A (+1d) |  | 0% → 100% | 0d → none |  | resources none → Space Planner; baseline start none → 2013-10-21; baseline finish none → 2013-10-23 |
| 7 | Space plan complete | 2013-10-22 → 2013-10-23 A (+1d) | 2013-10-22 → 2013-10-23 A (+1d) |  | 0% → 100% | 0d → none |  | baseline start none → 2013-10-23; baseline finish none → 2013-10-23 |
| 8 | **Furniture selection** | 2013-10-18 → 2013-10-22 A (+4d) | 2013-11-04 → 2013-11-07 (+3d) | 12d → 13d | 0% → 79% | 14.5d → 10d |  | baseline start none → 2013-10-22; baseline finish none → 2013-11-07 |
| 9 | Preview furniture selections | 2013-10-18 → 2013-10-22 A (+4d) | 2013-10-21 → 2013-10-25 A (+4d) | 2d → 4d | 0% → 100% | 14.5d → none | 5 → 5SS+1d | resources none → Office Manager; Administrative Assistant; baseline start none → 2013-10-22; baseline finish none → 2013-10-24 |
| 10 | Select new furniture | 2013-10-22 → 2013-10-28 A (+6d) | 2013-10-23 → 2013-10-29 A (+6d) |  | 0% → 100% | 14.5d → none |  | resources none → Office Manager; baseline start none → 2013-10-28; baseline finish none → 2013-10-29 |
| 11 | Order new furniture | 2013-10-24 → 2013-10-29 A (+5d) | 2013-10-24 → 2013-10-29 A (+5d) |  | 0% → 100% | 14.5d → none |  | resources none → Administrative Assistant; baseline start none → 2013-10-29; baseline finish none → 2013-10-29 |
| 12 | Delivery time | 2013-10-24 → 2013-10-29 A (+5d) | 2013-11-04 → 2013-11-07 (+3d) |  | 0% → 60% | 14.5d → 10d |  | constraint none → finish no earlier than 2009-11-01; resources none → Administrative Assistant [10%]; baseline start none → 2013-10-29; baseline finish none → 2013-11-07 |
| 13 | Furniture delivered | 2013-11-04 → 2013-11-07 (+3d) | 2013-11-04 → 2013-11-07 (+3d) |  |  | 14.5d → 10d |  | baseline start none → 2013-11-07; baseline finish none → 2013-11-07 |
| 14 | **Remodel workspace** | 2013-10-23 A | 2013-11-11 → 2013-11-05 A (-6d) | 14d → 9d | 0% → 100% | 0d → none |  | baseline start none → 2013-10-23; baseline finish none → 2013-11-05 |
| 15 | Hire contractor | 2013-10-23 A | 2013-10-28 A |  | 0% → 100% | 0d → none |  | resources none → President; Operations Manager; baseline start none → 2013-10-23; baseline finish none → 2013-10-28 |
| 16 | Remodel workspace | 2013-10-29 A | 2013-11-11 → 2013-11-04 A (-7d) | 2w → 1w | 0% → 100% | 0d → none |  | resources none → Contractor [200%]; baseline start none → 2013-10-29; baseline finish none → 2013-11-04 |
| 17 | Remodel complete | 2013-11-11 → 2013-11-05 A (-6d) | 2013-11-11 → 2013-11-05 A (-6d) |  | 0% → 100% | 0d → none |  | baseline start none → 2013-11-05; baseline finish none → 2013-11-05 |
| 18 | **New workspace** | 2013-11-12 → 2013-11-05 A (-7d) | 2013-11-25 → 2013-11-21 (-4d) | 9.5d → 12.5d | 0% → 17% | 0d → 0.5d |  | baseline start none → 2013-11-05; baseline finish none → 2013-11-21 |
| 19 | Hire mover | 2013-11-12 → 2013-11-05 A (-7d) | 2013-11-13 → 2013-11-06 (-7d) |  | 0% → 75% | 0d → 2.33d | none → 15SS | resources none → Office Manager; Operations Manager; baseline start none → 2013-11-05; baseline finish none → 2013-11-06 |
| 20 | Pack workspace | 2013-11-14 → 2013-11-11 A (-3d) | 2013-11-14 → 2013-11-12 (-2d) | 1d → 1.5d | 0% → 22% | 0d → -1.62d | 19 → 19, 15 | resources none → Operations Manager; Janitor; baseline start none → 2013-11-11; baseline finish none → 2013-11-12 |
| 21 | Move Equipment | 2013-11-15 → 2013-11-12 (-3d) | 2013-11-15 → 2013-11-12 (-3d) |  |  | 0d → -1.62d | 20 → 20FF | was named Move equipment; resources none → Mover; Office Manager; baseline start none → 2013-11-12; baseline finish none → 2013-11-12 |
| 22 | Remove existing furniture | 2013-11-15 → 2013-11-12 (-3d) | 2013-11-18 → 2013-11-13 (-5d) |  |  | 0d → -1d |  | resources none → Mover; baseline start none → 2013-11-12; baseline finish none → 2013-11-13 |
| 23 | Assemble new furniture | 2013-11-18 → 2013-11-14 (-4d) | 2013-11-20 → 2013-11-15 (-5d) |  |  | 0d → -2d | 22 → 22, 16 | resources none → Office Manager; Space Planner [125%]; baseline start none → 2013-11-14; baseline finish none → 2013-11-15 |
| 24 | Return equipment | 2013-11-20 → 2013-11-15 (-5d) | 2013-11-21 → 2013-11-18 (-3d) |  |  | 0d → 0.5d | 23 → 23FS-0.5d | resources none → Mover; Operations Manager; baseline start none → 2013-11-15; baseline finish none → 2013-11-18 |
| 25 | Unpack workspace | 2013-11-21 → 2013-11-18 (-3d) | 2013-11-22 → 2013-11-20 (-2d) | 1d → 2d |  | 0d → 0.5d |  | resources none → Mover; Administrative Assistant; baseline start none → 2013-11-18; baseline finish none → 2013-11-20 |
| 26 | Workspace final clean | 2013-11-22 → 2013-11-20 (-2d) | 2013-11-25 → 2013-11-21 (-4d) |  |  | 0d → 0.5d |  | resources none → Janitor [50%]; Mover [50%]; baseline start none → 2013-11-20; baseline finish none → 2013-11-21 |
| 27 | Workspace remodel complete | 2013-11-25 → 2013-11-22 (-3d) | 2013-11-25 → 2013-11-22 (-3d) |  |  |  | 18 → 26 | constraint none → must finish on 2013-11-22; baseline start none → 2013-11-22; baseline finish none → 2013-11-22 |

## Version 19 (saved 2013-08-02, file 7update.mpp)

Last finish 2013-11-22 → 2013-11-20 (-2d). Complete tasks 11 → 0.

Changed:

| ID | Task | Start | Finish | Duration | Complete | Total float | Other |
| --- | --- | --- | --- | --- | --- | --- | --- |
| 1 | **Office Workspace Remodel** | 2013-10-07 A → 2013-10-07 | 2013-11-22 → 2013-11-20 (-2d) | 34d → 32d | 74% → 0% |  | baseline finish 2013-11-22 → 2013-11-20 |
| 2 | **Space planning** | 2013-10-07 A → 2013-10-07 | 2013-10-23 A → 2013-10-22 (-1d) | 13d → 12d | 100% → 0% | none → 0d | baseline finish 2013-10-23 → 2013-10-22 |
| 3 | Interview space planners | 2013-10-07 A → 2013-10-07 | 2013-10-11 A → 2013-10-11 |  | 100% → 0% | none → 0d |  |
| 4 | Hire space planner | 2013-10-14 A → 2013-10-14 | 2013-10-15 A → 2013-10-15 |  | 100% → 0% | none → 0d |  |
| 5 | Meeting with space planner | 2013-10-16 A → 2013-10-16 | 2013-10-17 A → 2013-10-17 |  | 100% → 0% | none → 0d |  |
| 6 | Finalize space plan | 2013-10-21 A → 2013-10-18 (-3d) | 2013-10-23 A → 2013-10-22 (-1d) |  | 100% → 0% | none → 0d | baseline start 2013-10-21 → 2013-10-18; baseline finish 2013-10-23 → 2013-10-22 |
| 7 | Space plan complete | 2013-10-23 A → 2013-10-22 (-1d) | 2013-10-23 A → 2013-10-22 (-1d) |  | 100% → 0% | none → 0d | baseline start 2013-10-23 → 2013-10-22; baseline finish 2013-10-23 → 2013-10-22 |
| 8 | **Furniture selection** | 2013-10-22 A → 2013-10-21 (-1d) | 2013-11-07 → 2013-11-05 (-2d) | 13d → 12d | 79% → 0% |  | baseline start 2013-10-22 → 2013-10-21; baseline finish 2013-11-07 → 2013-11-05 |
| 9 | Preview furniture selections | 2013-10-22 A → 2013-10-21 (-1d) | 2013-10-25 A → 2013-10-23 (-2d) | 4d → 3d | 100% → 0% | none → 10d | baseline start 2013-10-22 → 2013-10-21; baseline finish 2013-10-24 → 2013-10-23 |
| 10 | Select new furniture | 2013-10-28 A → 2013-10-24 (-4d) | 2013-10-29 A → 2013-10-24 (-5d) | 2d → 1d | 100% → 0% | none → 10d | baseline start 2013-10-28 → 2013-10-24; baseline finish 2013-10-29 → 2013-10-24 |
| 11 | Order new furniture | 2013-10-29 A → 2013-10-25 (-4d) | 2013-10-29 A → 2013-10-25 (-4d) |  | 100% → 0% | none → 10d | baseline start 2013-10-29 → 2013-10-25; baseline finish 2013-10-29 → 2013-10-25 |
| 12 | Delivery time | 2013-10-29 A → 2013-10-25 (-4d) | 2013-11-07 → 2013-11-05 (-2d) |  | 60% → 0% |  | baseline start 2013-10-29 → 2013-10-25; baseline finish 2013-11-07 → 2013-11-05 |
| 13 | Furniture delivered | 2013-11-07 → 2013-11-05 (-2d) | 2013-11-07 → 2013-11-05 (-2d) |  |  |  | baseline start 2013-11-07 → 2013-11-05; baseline finish 2013-11-07 → 2013-11-05 |
| 14 | **Remodel workspace** | 2013-10-23 A → 2013-10-23 | 2013-11-05 A → 2013-11-04 (-1d) |  | 100% → 0% | none → 0d | baseline finish 2013-11-05 → 2013-11-04 |
| 15 | Hire contractor | 2013-10-23 A → 2013-10-23 | 2013-10-28 A → 2013-10-28 |  | 100% → 0% | none → 0d |  |
| 16 | Remodel workspace | 2013-10-29 A → 2013-10-29 | 2013-11-04 A → 2013-11-04 |  | 100% → 0% | none → 0d |  |
| 17 | Remodel complete | 2013-11-05 A → 2013-11-04 (-1d) | 2013-11-05 A → 2013-11-04 (-1d) |  | 100% → 0% | none → 0d | baseline start 2013-11-05 → 2013-11-04; baseline finish 2013-11-05 → 2013-11-04 |
| 18 | **New workspace** | 2013-11-05 A → 2013-11-05 | 2013-11-21 → 2013-11-19 (-2d) | 12.5d → 10.5d | 17% → 0% | 0.5d → 0d | baseline finish 2013-11-21 → 2013-11-19 |
| 19 | Hire mover | 2013-11-05 A → 2013-11-05 |  |  | 75% → 0% | 2.33d → 0d |  |
| 20 | Pack workspace | 2013-11-11 A → 2013-11-07 (-4d) | 2013-11-12 → 2013-11-07 (-5d) | 1.5d → 1d | 22% → 0% | -1.62d → 0d | baseline start 2013-11-11 → 2013-11-07; baseline finish 2013-11-12 → 2013-11-07 |
| 21 | Move Equipment | 2013-11-12 → 2013-11-07 (-5d) | 2013-11-12 → 2013-11-07 (-5d) |  |  | -1.62d → 0.88d | baseline start 2013-11-12 → 2013-11-07; baseline finish 2013-11-12 → 2013-11-07 |
| 22 | Remove existing furniture | 2013-11-12 → 2013-11-07 (-5d) | 2013-11-13 → 2013-11-11 (-2d) |  |  | -1d → 0.38d | baseline start 2013-11-12 → 2013-11-07; baseline finish 2013-11-13 → 2013-11-11 |
| 23 | Assemble new furniture | 2013-11-14 → 2013-11-12 (-2d) | 2013-11-15 → 2013-11-13 (-2d) |  |  | -2d → 0d | baseline start 2013-11-14 → 2013-11-12; baseline finish 2013-11-15 → 2013-11-13 |
| 24 | Return equipment | 2013-11-15 → 2013-11-13 (-2d) | 2013-11-18 → 2013-11-14 (-4d) |  |  |  | baseline start 2013-11-15 → 2013-11-13; baseline finish 2013-11-18 → 2013-11-14 |
| 25 | Unpack workspace | 2013-11-18 → 2013-11-14 (-4d) | 2013-11-20 → 2013-11-18 (-2d) |  |  |  | baseline start 2013-11-18 → 2013-11-14; baseline finish 2013-11-20 → 2013-11-18 |
| 26 | Workspace final clean | 2013-11-20 → 2013-11-18 (-2d) | 2013-11-21 → 2013-11-19 (-2d) |  |  |  | baseline start 2013-11-20 → 2013-11-18; baseline finish 2013-11-21 → 2013-11-19 |
| 27 | Workspace remodel complete | 2013-11-22 → 2013-11-20 (-2d) | 2013-11-22 → 2013-11-20 (-2d) |  |  |  | constraint must finish on 2013-11-22 → must finish on 2013-11-20; baseline start 2013-11-22 → 2013-11-20; baseline finish 2013-11-22 → 2013-11-20 |

## Version 20 (data date 2013-11-04, saved 2013-08-03, file 8filter.mpp)

Last finish 2013-11-20 → 2013-11-22 (+2d). Complete tasks 0 → 11.

Changed:

| ID | Task | Start | Finish | Duration | Complete | Total float | Other |
| --- | --- | --- | --- | --- | --- | --- | --- |
| 1 | **Office Workspace Remodel** | 2013-10-07 A | 2013-11-20 → 2013-11-22 (+2d) | 32d → 34d | 0% → 74% |  | baseline finish 2013-11-20 → 2013-11-22 |
| 2 | **Space planning** | 2013-10-07 A | 2013-10-22 → 2013-10-23 A (+1d) | 12d → 13d | 0% → 100% | 0d → none | baseline finish 2013-10-22 → 2013-10-23 |
| 3 | Interview space planners | 2013-10-07 A | 2013-10-11 A |  | 0% → 100% | 0d → none |  |
| 4 | Hire space planner | 2013-10-14 A | 2013-10-15 A |  | 0% → 100% | 0d → none |  |
| 5 | Meeting with space planner | 2013-10-16 A | 2013-10-17 A |  | 0% → 100% | 0d → none |  |
| 6 | Finalize space plan | 2013-10-18 → 2013-10-21 A (+3d) | 2013-10-22 → 2013-10-23 A (+1d) |  | 0% → 100% | 0d → none | baseline start 2013-10-18 → 2013-10-21; baseline finish 2013-10-22 → 2013-10-23 |
| 7 | Space plan complete | 2013-10-22 → 2013-10-23 A (+1d) | 2013-10-22 → 2013-10-23 A (+1d) |  | 0% → 100% | 0d → none | baseline start 2013-10-22 → 2013-10-23; baseline finish 2013-10-22 → 2013-10-23 |
| 8 | **Furniture selection** | 2013-10-21 → 2013-10-22 A (+1d) | 2013-11-05 → 2013-11-07 (+2d) | 12d → 13d | 0% → 79% |  | baseline start 2013-10-21 → 2013-10-22; baseline finish 2013-11-05 → 2013-11-07 |
| 9 | Preview furniture selections | 2013-10-21 → 2013-10-22 A (+1d) | 2013-10-23 → 2013-10-24 A (+1d) |  | 0% → 100% | 10d → none | baseline start 2013-10-21 → 2013-10-22; baseline finish 2013-10-23 → 2013-10-24 |
| 10 | Select new furniture | 2013-10-24 → 2013-10-28 A (+4d) | 2013-10-24 → 2013-10-30 A (+6d) | 1d → 3d | 0% → 100% | 10d → none | baseline start 2013-10-24 → 2013-10-28; baseline finish 2013-10-24 → 2013-10-29 |
| 11 | Order new furniture | 2013-10-25 → 2013-10-29 A (+4d) | 2013-10-25 → 2013-10-29 A (+4d) |  | 0% → 100% | 10d → none | baseline start 2013-10-25 → 2013-10-29; baseline finish 2013-10-25 → 2013-10-29 |
| 12 | Delivery time | 2013-10-25 → 2013-10-29 A (+4d) | 2013-11-05 → 2013-11-07 (+2d) |  | 0% → 60% |  | baseline start 2013-10-25 → 2013-10-29; baseline finish 2013-11-05 → 2013-11-07 |
| 13 | Furniture delivered | 2013-11-05 → 2013-11-07 (+2d) | 2013-11-05 → 2013-11-07 (+2d) |  |  |  | baseline start 2013-11-05 → 2013-11-07; baseline finish 2013-11-05 → 2013-11-07 |
| 14 | **Remodel workspace** | 2013-10-23 A | 2013-11-04 → 2013-11-05 A (+1d) |  | 0% → 100% | 0d → none | baseline finish 2013-11-04 → 2013-11-05 |
| 15 | Hire contractor | 2013-10-23 A | 2013-10-28 A |  | 0% → 100% | 0d → none |  |
| 16 | Remodel workspace | 2013-10-29 A | 2013-11-04 A |  | 0% → 100% | 0d → none |  |
| 17 | Remodel complete | 2013-11-04 → 2013-11-05 A (+1d) | 2013-11-04 → 2013-11-05 A (+1d) |  | 0% → 100% | 0d → none | baseline start 2013-11-04 → 2013-11-05; baseline finish 2013-11-04 → 2013-11-05 |
| 18 | **New workspace** | 2013-11-05 A | 2013-11-19 → 2013-11-21 (+2d) | 10.5d → 12.5d | 0% → 17% | 0d → 0.5d | baseline finish 2013-11-19 → 2013-11-21 |
| 19 | Hire mover | 2013-11-05 A |  |  | 0% → 75% | 0d → 2.33d |  |
| 20 | Pack workspace | 2013-11-07 → 2013-11-11 A (+4d) | 2013-11-07 → 2013-11-12 (+5d) | 1d → 1.5d | 0% → 22% | 0d → -1.62d | baseline start 2013-11-07 → 2013-11-11; baseline finish 2013-11-07 → 2013-11-12 |
| 21 | Move Equipment | 2013-11-07 → 2013-11-12 (+5d) | 2013-11-07 → 2013-11-12 (+5d) |  |  | 0.88d → -1.62d | baseline start 2013-11-07 → 2013-11-12; baseline finish 2013-11-07 → 2013-11-12 |
| 22 | Remove existing furniture | 2013-11-07 → 2013-11-12 (+5d) | 2013-11-11 → 2013-11-13 (+2d) |  |  | 0.38d → -1d | baseline start 2013-11-07 → 2013-11-12; baseline finish 2013-11-11 → 2013-11-13 |
| 23 | Assemble new furniture | 2013-11-12 → 2013-11-14 (+2d) | 2013-11-13 → 2013-11-15 (+2d) |  |  | 0d → -2d | baseline start 2013-11-12 → 2013-11-14; baseline finish 2013-11-13 → 2013-11-15 |
| 24 | Return equipment | 2013-11-13 → 2013-11-15 (+2d) | 2013-11-14 → 2013-11-18 (+4d) |  |  |  | baseline start 2013-11-13 → 2013-11-15; baseline finish 2013-11-14 → 2013-11-18 |
| 25 | Unpack workspace | 2013-11-14 → 2013-11-18 (+4d) | 2013-11-18 → 2013-11-20 (+2d) |  |  |  | baseline start 2013-11-14 → 2013-11-18; baseline finish 2013-11-18 → 2013-11-20 |
| 26 | Workspace final clean | 2013-11-18 → 2013-11-20 (+2d) | 2013-11-19 → 2013-11-21 (+2d) |  |  |  | baseline start 2013-11-18 → 2013-11-20; baseline finish 2013-11-19 → 2013-11-21 |
| 27 | Workspace remodel complete | 2013-11-20 → 2013-11-22 (+2d) | 2013-11-20 → 2013-11-22 (+2d) |  |  |  | constraint must finish on 2013-11-20 → must finish on 2013-11-22; baseline start 2013-11-20 → 2013-11-22; baseline finish 2013-11-20 → 2013-11-22 |

## Version 21 (data date 2010-01-09, saved 2013-08-03, file 4report.mpp)

Last finish 2013-11-22 → 2013-11-12 (-10d). Complete tasks 11 → 15.

Changed:

| ID | Task | Start | Finish | Duration | Complete | Total float | Predecessors | Other |
| --- | --- | --- | --- | --- | --- | --- | --- | --- |
| 1 | **Office Workspace Remodel** |  | 2013-11-22 → 2013-11-12 (-10d) | 34d → 27d | 74% → 88% |  |  | baseline start 2013-10-07 → none; baseline finish 2013-11-22 → none |
| 2 | **Space planning** |  |  |  |  |  |  | baseline start 2013-10-07 → none; baseline finish 2013-10-23 → none |
| 3 | Interview space planners |  |  |  |  |  |  | baseline start 2013-10-07 → none; baseline finish 2013-10-11 → none |
| 4 | Hire space planner |  | 2013-10-15 A → 2013-10-14 A (-1d) | 2d → 1d |  |  |  | baseline start 2013-10-14 → none; baseline finish 2013-10-15 → none |
| 5 | Meeting with space planner | 2013-10-16 A → 2013-10-15 A (-1d) |  | 2d → 3d |  |  |  | baseline start 2013-10-16 → none; baseline finish 2013-10-17 → none |
| 6 | Finalize space plan |  |  |  |  |  |  | baseline start 2013-10-21 → none; baseline finish 2013-10-23 → none |
| 7 | Space plan complete | 2013-10-23 A → 2013-10-22 A (-1d) | 2013-10-23 A → 2013-10-22 A (-1d) |  |  |  |  | baseline start 2013-10-23 → none; baseline finish 2013-10-23 → none |
| 8 | **Furniture selection** | 2013-10-22 A → 2013-10-21 A (-1d) | 2013-11-07 → 2013-11-04 A (-3d) | 13d → 10.5d | 79% → 100% | 10d → none |  | baseline start 2013-10-22 → none; baseline finish 2013-11-07 → none |
| 9 | Preview furniture selections | 2013-10-22 A → 2013-10-21 A (-1d) | 2013-10-24 A → 2013-10-22 A (-2d) | 3d → 2d |  |  |  | resources Office Manager; Administrative Assistant → Office Manager; Operations Manager; Administrative Assistant; baseline start 2013-10-22 → none; baseline finish 2013-10-24 → none |
| 10 | Select new furniture | 2013-10-28 A → 2013-10-22 A (-6d) | 2013-10-30 A → 2013-10-23 A (-7d) | 3d → 1.5d |  |  |  | resources Office Manager → Office Manager; Operations Manager; baseline start 2013-10-28 → none; baseline finish 2013-10-29 → none |
| 11 | Order new furniture | 2013-10-29 A → 2013-10-23 A (-6d) | 2013-10-29 A → 2013-10-23 A (-6d) |  |  |  |  | baseline start 2013-10-29 → none; baseline finish 2013-10-29 → none |
| 12 | Delivery time | 2013-10-29 A → 2013-10-24 A (-5d) | 2013-11-07 → 2013-11-04 A (-3d) |  | 60% → 100% | 10d → none |  | constraint finish no earlier than 2009-11-01 → finish no earlier than 2011-11-02; baseline start 2013-10-29 → none; baseline finish 2013-11-07 → none |
| 13 | Furniture delivered | 2013-11-07 → 2013-11-01 A (-6d) | 2013-11-07 → 2013-11-01 A (-6d) |  | 0% → 100% | 10d → none |  | baseline start 2013-11-07 → none; baseline finish 2013-11-07 → none |
| 14 | **Remodel workspace** |  | 2013-11-05 A → 2013-11-05 |  | 100% → 94% | none → 6d |  | baseline start 2013-10-23 → none; baseline finish 2013-11-05 → none |
| 15 | Hire contractor |  |  |  |  |  |  | baseline start 2013-10-23 → none; baseline finish 2013-10-28 → none |
| 16 | Remodel workspace |  | 2013-11-04 A → 2013-11-04 |  | 100% → 90% | none → 1.5d |  | baseline start 2013-10-29 → none; baseline finish 2013-11-04 → none |
| 17 | Remodel complete | 2013-11-05 A → 2013-11-05 | 2013-11-05 A → 2013-11-05 |  | 100% → 0% | none → 6d |  | constraint none → start no earlier than 2013-11-05; baseline start 2013-11-05 → none; baseline finish 2013-11-05 → none |
| 18 | **New workspace** | 2013-11-05 A → 2013-10-23 A (-13d) | 2013-11-21 → 2013-11-12 (-9d) | 12.5d → 15d | 17% → 57% | 0.5d → 0d | 14 → none | baseline start 2013-11-05 → none; baseline finish 2013-11-21 → none |
| 19 | Hire mover | 2013-11-05 A → 2013-10-23 A (-13d) | 2013-11-06 → 2013-10-28 A (-9d) | 2d → 4d | 75% → 100% | 2.33d → none |  | resources Office Manager; Operations Manager → Office Manager; baseline start 2013-11-05 → none; baseline finish 2013-11-06 → none |
| 20 | Pack workspace | 2013-11-11 A → 2013-10-29 A (-13d) | 2013-11-12 → 2013-10-29 A (-14d) | 1.5d → 1d | 22% → 100% | -1.62d → none |  | resources Operations Manager; Janitor → President; Janitor; baseline start 2013-11-11 → none; baseline finish 2013-11-12 → none |
| 21 | Move Equipment | 2013-11-12 → 2013-10-29 A (-14d) | 2013-11-12 → 2013-10-29 A (-14d) |  | 0% → 100% | -1.62d → none |  | resources Mover; Office Manager → Mover; Operations Manager; baseline start 2013-11-12 → none; baseline finish 2013-11-12 → none |
| 22 | Remove existing furniture | 2013-11-12 → 2013-10-30 A (-13d) | 2013-11-13 → 2013-10-30 A (-14d) |  | 0% → 100% | -1d → none |  | baseline start 2013-11-12 → none; baseline finish 2013-11-13 → none |
| 23 | Assemble new furniture | 2013-11-14 → 2013-11-05 (-9d) | 2013-11-15 → 2013-11-06 (-9d) |  |  | -2d → 1.5d |  | resources Office Manager; Space Planner [125%] → Office Manager; Space Planner [116.7%]; baseline start 2013-11-14 → none; baseline finish 2013-11-15 → none |
| 24 | Return equipment | 2013-11-15 → 2013-11-06 (-9d) | 2013-11-18 → 2013-11-07 (-11d) |  |  | 0.5d → 1.5d |  | baseline start 2013-11-15 → none; baseline finish 2013-11-18 → none |
| 25 | Unpack workspace | 2013-11-18 → 2013-11-11 (-7d) | 2013-11-20 → 2013-11-11 (-9d) | 2d → 1d |  | 0.5d → 0d |  | constraint none → start no earlier than 2013-11-09; baseline start 2013-11-18 → none; baseline finish 2013-11-20 → none |
| 26 | Workspace final clean | 2013-11-20 → 2013-11-12 (-8d) | 2013-11-21 → 2013-11-12 (-9d) |  |  | 0.5d → 0d |  | constraint none → start no earlier than 2013-11-09; baseline start 2013-11-20 → none; baseline finish 2013-11-21 → none |
| 27 | Workspace remodel complete | 2013-11-22 → 2013-11-12 (-10d) | 2013-11-22 → 2013-11-12 (-10d) |  |  |  | 26 → 18 | constraint must finish on 2013-11-22 → start no earlier than 2013-11-12; baseline start 2013-11-22 → none; baseline finish 2013-11-22 → none |

## Version 22 (saved 2013-08-24, file 3rescal.mpp)

Last finish 2013-11-12 → 2013-11-22 (+10d). Complete tasks 15 → 0.

Changed:

| ID | Task | Start | Finish | Duration | Complete | Total float | Predecessors | Other |
| --- | --- | --- | --- | --- | --- | --- | --- | --- |
| 1 | **Office Workspace Remodel** | 2013-10-07 A → 2013-10-07 | 2013-11-12 → 2013-11-22 (+10d) | 27d → 34.5d | 88% → 0% |  |  |  |
| 2 | **Space planning** | 2013-10-07 A → 2013-10-07 | 2013-10-23 A → 2013-10-22 (-1d) | 13d → 12d | 100% → 0% | none → 0d |  |  |
| 3 | Interview space planners | 2013-10-07 A → 2013-10-07 | 2013-10-11 A → 2013-10-11 |  | 100% → 0% | none → 0d |  | resources Operations Manager; Office Manager; President [25%] → President; Operations Manager; Office Manager |
| 4 | Hire space planner | 2013-10-14 A → 2013-10-14 | 2013-10-14 A → 2013-10-15 (+1d) | 1d → 2d | 100% → 0% | none → 0d |  |  |
| 5 | Meeting with space planner | 2013-10-15 A → 2013-10-16 (+1d) | 2013-10-17 A → 2013-10-17 | 3d → 2d | 100% → 0% | none → 0d |  |  |
| 6 | Finalize space plan | 2013-10-21 A → 2013-10-18 (-3d) | 2013-10-23 A → 2013-10-22 (-1d) |  | 100% → 0% | none → 0d |  |  |
| 7 | Space plan complete | 2013-10-22 A → 2013-10-22 | 2013-10-22 A → 2013-10-22 |  | 100% → 0% | none → 0d |  |  |
| 8 | **Furniture selection** | 2013-10-21 A → 2013-10-17 (-4d) | 2013-11-04 A → 2013-11-01 (-3d) | 10.5d → 12d | 100% → 0% | none → 14.5d |  |  |
| 9 | Preview furniture selections | 2013-10-21 A → 2013-10-17 (-4d) | 2013-10-22 A → 2013-10-18 (-4d) |  | 100% → 0% | none → 14.5d |  |  |
| 10 | Select new furniture | 2013-10-22 A → 2013-10-21 (-1d) | 2013-10-23 A → 2013-10-22 (-1d) | 1.5d → 2d | 100% → 0% | none → 14.5d |  |  |
| 11 | Order new furniture | 2013-10-23 A → 2013-10-23 | 2013-10-23 A → 2013-10-23 |  | 100% → 0% | none → 14.5d |  |  |
| 12 | Delivery time | 2013-10-24 A → 2013-10-23 (-1d) | 2013-11-04 A → 2013-11-01 (-3d) |  | 100% → 0% | none → 14.5d |  | constraint finish no earlier than 2011-11-02 → none |
| 13 | Furniture delivered | 2013-11-01 A → 2013-11-01 | 2013-11-01 A → 2013-11-01 |  | 100% → 0% | none → 14.5d |  |  |
| 14 | **Remodel workspace** | 2013-10-23 A → 2013-10-23 | 2013-11-05 → 2013-11-11 (+6d) | 9d → 14d | 94% → 0% | 6d → 0d |  |  |
| 15 | Hire contractor | 2013-10-23 A → 2013-10-23 | 2013-10-28 A → 2013-10-28 |  | 100% → 0% | none → 0d |  |  |
| 16 | Remodel workspace | 2013-10-29 A → 2013-10-29 | 2013-11-04 → 2013-11-11 (+7d) | 1w → 2w | 90% → 0% | 1.5d → 0d |  | resources Contractor [200%] → Contractor |
| 17 | Remodel complete | 2013-11-05 → 2013-11-11 (+6d) | 2013-11-05 → 2013-11-11 (+6d) |  |  | 6d → 0d |  | constraint start no earlier than 2013-11-05 → none |
| 18 | **New workspace** | 2013-10-23 A → 2013-11-12 (+20d) | 2013-11-12 → 2013-11-22 (+10d) | 15d → 8.5d | 57% → 0% |  | none → 14 |  |
| 19 | Hire mover | 2013-10-23 A → 2013-11-12 (+20d) | 2013-10-28 A → 2013-11-13 (+16d) | 4d → 2d | 100% → 0% | none → 0d | 15SS → none | resources Office Manager → Office Manager; Operations Manager |
| 20 | Pack workspace | 2013-10-29 A → 2013-11-14 (+16d) | 2013-10-29 A → 2013-11-14 (+16d) |  | 100% → 0% | none → 0d | 19, 15 → 19 | resources President; Janitor → Operations Manager; Mover |
| 21 | Move Equipment | 2013-10-29 A → 2013-11-14 (+16d) | 2013-10-29 A → 2013-11-14 (+16d) |  | 100% → 0% | none → 0d |  |  |
| 22 | Remove existing furniture | 2013-10-30 A → 2013-11-15 (+16d) | 2013-10-30 A → 2013-11-15 (+16d) |  | 100% → 0% | none → 0d |  |  |
| 23 | Assemble new furniture | 2013-11-05 → 2013-11-18 (+13d) | 2013-11-06 → 2013-11-19 (+13d) |  |  | 1.5d → 0d | 22, 16 → 22 | resources Office Manager; Space Planner [116.7%] → Mover; Space Planner |
| 24 | Return equipment | 2013-11-06 → 2013-11-19 (+13d) | 2013-11-07 → 2013-11-20 (+13d) |  |  | 1.5d → 0d |  |  |
| 25 | Unpack workspace | 2013-11-11 → 2013-11-20 (+9d) | 2013-11-11 → 2013-11-21 (+10d) |  |  |  |  | constraint start no earlier than 2013-11-09 → none |
| 26 | Workspace final clean | 2013-11-12 → 2013-11-21 (+9d) | 2013-11-12 → 2013-11-22 (+10d) |  |  |  |  | constraint start no earlier than 2013-11-09 → none; resources Janitor [50%]; Mover [50%] → Janitor |
| 27 | Workspace remodel complete | 2013-11-12 → 2013-11-22 (+10d) | 2013-11-12 → 2013-11-22 (+10d) |  |  |  |  | constraint start no earlier than 2013-11-12 → none |
